# US CMS Milestones

Schedule from MS Project, 2001-06-15 to 2010-05-31, A marks actual dates.
Fermilab

## Calendars

- 250 Day: Mon-Fri 08:00-12:00, 13:00-17:00; Sat-Sun off. Exceptions (off unless hours are given): 2001-12-20 to 2001-12-21, 2001-12-24 to 2001-12-28, 2001-12-31 to 2002-01-03, 2002-12-20, 2002-12-23 to 2002-12-27, 2002-12-30 to 2003-01-03, 2003-12-22 to 2003-12-26, 2003-12-29 to 2004-01-02, 2004-01-05 to 2004-01-06, 2004-12-22 to 2004-12-24, 2004-12-27 to 2004-12-31, 2005-01-03 to 2005-01-05, 2005-12-22 to 2005-12-23, 2005-12-26 to 2005-12-30, 2006-01-02 to 2006-01-04, 2006-12-21 to 2006-12-22, 2006-12-25 to 2006-12-29, 2007-01-01, 2007-01-02 08:00-12:00, 13:00-17:00, 2007-01-03, 2007-12-20 08:00-12:00, 13:00-17:00, 2007-12-21, 2007-12-24 to 2007-12-28, 2007-12-31 08:00-12:00, 13:00-17:00, 2008-01-01, 2008-01-02 08:00-12:00, 13:00-17:00, 2008-01-03 to 2008-01-04, 2008-12-22 to 2008-12-26, 2008-12-29 to 2009-01-02, 2009-01-05, 2009-12-22 to 2009-12-25, 2009-12-28 to 2010-01-01, 2010-01-04 to 2010-01-05.

## Schedule

| ID | WBS | Task | Type | Duration | Start | Finish | Complete | Remaining | Baseline start | Baseline finish | Baseline duration | Total slack | Constraint | Text7 | Text1 | Text10 | Text11 | Text9 |
| --- | --- | --- | --- | --- | --- | --- | --- | --- | --- | --- | --- | --- | --- | --- | --- | --- | --- | --- |
| 1 | 1 | **Level 1 DOE (SC1) Milestones** |  | 2242d? | 2001-06-15 | 2010-05-31 |  |  | 2004-02-28 | 2008-08-29 | 1132d | 0d |  | N/A |  |  |  |  |
| 2 | 1.1 | CD0 - Approve Mission Need | milestone | 1d? | 2001-06-15 | 2001-06-17 |  |  |  | 2001-06-17 |  | 2241d | finish no earlier than 2001-06-17 | 0 days | DOE | ML1 | MS1_PM000 |  |
| 3 | 1.2 | CD1 - Approve Preliminary Baseline Range | milestone | 1d? | 2002-10-15 | 2002-10-16 |  |  |  | 2002-10-16 |  | 1905d | finish no earlier than 2002-10-16 | 0 days | DOE | ML1 | MS1_PM005 |  |
| 4 | 1.3 | CD2a - Approve Long-Lead Procurement Budget | milestone | 1d? | 2004-07-29 | 2004-07-30 |  |  |  | 2004-07-30 |  | 1461d | finish no earlier than 2004-07-30 | 0 days | DOE | ML1 | MS1_PM015 |  |
| 5 | 1.4 | CD3a - Approve Start of Long Lead Procurement | milestone | 1d? | 2004-10-28 | 2004-10-29 |  |  |  | 2004-10-29 |  | 1396d | finish no earlier than 2004-10-29 | 0 days | DOE | ML1 | MS1_PM025 |  |
| 6 | 1.5 | CD2b - Approve Performance Baseline | milestone | 1d? | 2005-03-30 | 2005-03-31 |  |  |  | 2005-03-31 |  | 1298d | finish no earlier than 2005-03-31 | 0 days | DOE | ML1 | MS1_PM020 |  |
| 7 | 1.6 | CD3b - Approve Start of Construction | milestone | 16d? | 2006-02-28 | 2006-03-21 |  |  |  | 2006-02-28 |  | 1054d | finish no earlier than 2006-03-21 | 0 days | DOE | ML1 | MS1_PM030 |  |
| 8 | 1.7 | CD4a - Start of Near Hall Operations | milestone | 1d? | 2009-07-31 | 2009-07-31 |  |  |  |  |  | 205d | finish no earlier than 2009-07-31 | 0 days | DOE | ML1 | MS1_PM035 |  |
| 9 | 1.8 | CD4b - Start of Far Hall Ops - Project Complete | milestone | 1d? | 2010-05-31 | 2010-05-31 |  |  |  |  |  | 0d | finish no earlier than 2010-05-31 | 0 days | DOE | ML1 | MS1_PM040 |  |
| 10 | 2 | **Level 2 DOE (SSO) Milestones** |  | 1488d | 2004-04-30 A | 2010-04-08 | 99% | 0d | 2004-02-28 | 2008-08-29 | 1132d | 37d |  | N/A |  |  |  |  |
| 11 | 2.1 | Prelim Safety Assessment (PSAD) Doc Complete | milestone | 0d | 2004-04-30 A | 2004-04-30 A | 100% |  | 2004-04-30 | 2004-04-30 | 0d |  | finish no later than 2004-04-30 | 0 days | PM | ML2 | MS2_PM045 |  |
| 12 | 2.2 | DOE External Independent Review (EIR) Complete | milestone | 0d | 2004-06-15 A | 2004-06-15 A | 100% |  | 2004-06-15 | 2004-06-15 | 0d |  | finish no later than 2004-06-15 | 0 days | PM | ML2 | MS2_PM035 | apm/dd |
| 13 | 2.3 | Fire Hazard Analysis Approved | milestone | 0d | 2005-08-15 A | 2005-08-15 A | 100% |  | 2005-05-31 | 2005-06-30 | 0d |  | finish no earlier than 2005-08-15 | 0 days | PM | ML2 | MS2_PM040 |  |
| 14 | 2.4 | Prelim Safety Assessment (PSAD) Doc Approved | milestone | 456d | 2004-04-30 A | 2006-02-28 A | 100% |  | 2004-04-30 | 2006-02-28 | 0d |  | finish no later than 2004-04-30 | 0 days | PM | ML2 | MS2_PM055 |  |
| 15 | 2.5 | Delivery of Undulator 1st Articles to MMF | milestone | 0d | 2006-06-15 A | 2006-06-15 A | 100% |  | 2006-07-03 | 2006-07-03 | 0d |  | finish no earlier than 2006-06-15 | 0 days | UN | ML2 | MS2_UN010 |  |
| 16 | 2.6 | Sector 20/Alcove Beneficial Occupancy | milestone | 0d | 2006-04-14 A | 2006-04-14 A | 100% |  | 2006-07-21 | 2006-07-21 | 0d |  | finish no earlier than 2006-04-14 | 0 days | CF | ML2 | MS2BO_005 |  |
| 17 | 2.7 | MMF Qualified & Ready to Measure Prod Undulators | milestone | 0d | 2006-08-28 | 2006-08-28 |  |  | 2006-08-28 | 2006-11-27 | 0d | 940d | finish no earlier than 2006-08-28 | 0 days | UN | ML2 | MS2_UN005 |  |
| 18 | 2.8 | Research Yards Mods Beneficial Occupancy | milestone | 0d | 2006-08-30 | 2006-08-30 |  |  | 2006-10-20 | 2006-10-20 | 0d | 938d | finish no earlier than 2006-08-30 | 0 days | CF | ML2 | MS2BO_025 |  |
| 19 | 2.9 | Start Injector Commissioning (Drive Laser) | milestone | 0d | 2007-01-16 | 2007-01-16 |  |  | 2006-11-20 | 2007-01-29 | 0d | 848d | finish no earlier than 2007-01-16 | 0 days | IJ | ML2 | MS2_IJ0010 | apm/dd |
| 20 | 2.10 | Injector Laser Commissioning Review Complete | milestone | 0d | 2006-12-01 | 2006-12-01 |  |  | 2006-09-18 | 2007-01-31 | 0d | 871d | finish no earlier than 2006-12-01 | 0 days | IJ | ML2 | MS2_IJ0027 | apm/dd |
| 21 | 2.11 | Start Linac (Li20-Li30) Commissioning | milestone | 0d | 2008-02-04 | 2008-02-04 |  |  | 2008-03-04 | 2008-03-03 | 0d | 583d | finish no earlier than 2008-02-04 | 0 days | LN | ML2 | MS2_LN025 |  |
| 22 | 2.12 | Linac (Li20-Li30) Commissioning Complete | milestone | 0d | 2008-09-30 | 2008-09-30 |  |  | 2008-03-04 |  | 0d | 412d | finish no earlier than 2008-09-30 | 0 days | LN | ML2 | MS2_LN032 |  |
| 23 | 2.13 | Final Safety Analysis Document (FSAD) Approved | milestone | 0d | 2008-10-15 | 2008-10-15 |  |  | 2008-03-31 | 2008-03-31 | 0d | 401d | finish no earlier than 2008-10-15 | 0 days | PM | ML2 | MS2_PM005 |  |
| 24 | 2.14 | Linac Water/Power Available | milestone | 0d | 2007-03-29 | 2007-03-29 |  |  | 2007-07-11 | 2007-07-11 | 0d | 796d | finish no earlier than 2007-03-29 | 0 days | CF | ML2 | MS2BO_020 |  |
| 25 | 2.15 | Start Injector Commissioning(UV Beam to Cathode) | milestone | 0d | 2007-04-05 | 2007-04-05 |  |  | 2007-07-20 | 2007-04-09 | 0d | 791d | finish no earlier than 2007-04-05 | 0 days | IJ | ML2 | MS2_IJ0020 | apm/dd |
| 26 | 2.16 | Injector Accelerator Readiness Review (ARR) Comp | milestone | 0d | 2007-03-30 | 2007-03-30 |  |  | 2007-05-18 | 2007-01-31 | 0d | 795d | finish no earlier than 2007-03-30 | 0 days | IJ | ML2 | MS2_IJ0030 | apm/dd |
| 27 | 2.17 | XE Start Installation in NEH | milestone | 0d | 2008-09-18 | 2008-09-18 |  |  | 2007-10-12 | 2008-05-20 | 0d | 420d | finish no earlier than 2008-09-18 | 0 days | XE | ML2 | MS2_XE060 |  |
| 28 | 2.18 | XE Start Installation in FEH | milestone | 0d | 2009-09-01 | 2009-09-01 |  |  | 2007-10-12 | 2008-08-20 | 0d | 183d | finish no earlier than 2009-09-01 | 0 days | XE | ML2 | MS2_XE050 |  |
| 29 | 2.19 | AMO Ready for Basic Expmnts (CD4a) | milestone | 0d | 2009-02-26 | 2009-02-26 |  |  | 2007-10-12 |  | 0d | 316d | finish no earlier than 2009-02-26 | 0 days | XE | ML2 | MS2_XE065 |  |
| 30 | 2.20 | 2-D Detector Shipped to SLAC | milestone | 0d | 2009-03-13 | 2009-03-13 |  |  | 2008-01-03 | 2007-12-05 | 0d | 305d | finish no earlier than 2009-03-13 | 0 days | XE | ML2 | MS2_XE015 |  |
| 31 | 2.21 | XT Start FEE Installation | milestone | 0d | 2008-09-22 | 2008-09-22 |  |  | 2007-10-05 | 2008-05-20 | 0d | 418d | finish no earlier than 2008-09-22 | 0 days | XT | ML2 | MS2_XT100 |  |
| 32 | 2.22 | Start Installation of Undulator Facility | milestone | 0d | 2008-02-04 | 2008-02-04 |  |  | 2007-07-02 | 2008-05-20 | 0d | 583d | finish no earlier than 2008-02-04 | 0 days | UN | ML2 | MS2_UN105 |  |
| 33 | 2.23 | Start Installation of Beam Transport Hall | milestone | 0d | 2008-02-04 | 2008-02-04 |  |  | 2008-01-03 | 2008-05-20 | 0d | 583d | finish no earlier than 2008-02-04 | 0 days | LN | ML2 | MS2_LN110 |  |
| 34 | 2.24 | LCLS ARR Complete | milestone | 0d | 2009-02-09 | 2009-02-09 |  |  | 2008-06-09 | 2008-07-11 | 0d | 329d | finish no earlier than 2009-02-09 | 0 days | PM | ML2 | MS2_PM030 |  |
| 35 | 2.25 | Start Linac-to-Undulator (LTU) Commissioning | milestone | 0d | 2009-02-09 | 2009-02-09 |  |  | 2008-03-04 | 2008-07-31 | 0d | 329d | finish no earlier than 2009-02-09 | 0 days | LN | ML2 | MS2_LN015 |  |
| 36 | 2.26 | Start Undulator Commissioning (1st Light) | milestone | 0d | 2009-05-05 | 2009-05-05 |  |  | 2008-08-18 | 2008-08-18 | 0d | 268d | finish no earlier than 2009-05-05 | 0 days | UN | ML2 | MS2_UN025 |  |
| 37 | 2.27 | First X-Rays into NEH | milestone | 0d | 2009-05-05 | 2009-05-05 |  |  | 2008-08-18 | 2008-10-08 | 0d | 268d | finish no earlier than 2009-05-05 | 0 days | XT | ML2 | MS2_XT005 |  |
| 38 | 2.28 | XT Start Tunnel Installation | milestone | 0d | 2009-08-12 | 2009-08-12 |  |  | 2008-08-18 | 2008-08-20 | 0d | 197d | finish no earlier than 2009-08-12 | 0 days | XT | ML2 | MS2_XT050 |  |
| 39 | 2.29 | First X-Rays into FEH | milestone | 0d | 2010-04-08 | 2010-04-08 |  |  | 2008-08-18 |  | 0d | 37d | finish no earlier than 2010-04-08 | 0 days | XT | ML2 | MS2_XT075 |  |
| 40 | 2.30 | Start NEH Commissioning with Beam | milestone | 0d | 2009-07-13 | 2009-07-13 |  |  | 2008-08-18 | 2008-10-02 | 0d | 219d | finish no earlier than 2009-07-13 | 0 days | XE | ML2 | MS2_XE005 |  |

| ID | WBS | Task | Type | Duration | Start | Finish | Complete | Remaining | Baseline start | Baseline finish | Baseline duration | Total slack | Constraint | Text1 | Text10 | Text11 | Text9 |
| --- | --- | --- | --- | --- | --- | --- | --- | --- | --- | --- | --- | --- | --- | --- | --- | --- | --- |
| 41 | 3 | **Level 3 SLAC (LCLS PO) Milestones** |  | 1510d? | 2004-02-28 A | 2010-03-08 |  | 1510d? |  |  |  | 60d |  |  |  |  |  |
| 42 | 3.1 | **Project Management (WBS 1.01)** |  | 1219d | 2004-02-28 A | 2009-01-08 |  | 1219d |  |  |  | 351d |  |  |  |  |  |
| 43 | 3.1.1 | Advanced Procurement Management Plan Complete | milestone | 0d | 2004-02-28 A | 2004-02-28 A | 100% |  | 2004-02-28 | 2004-02-28 | 0d |  | finish no later than 2004-02-28 | PM | ML3 | MS3_PM025 |  |
| 44 | 3.1.2 | Resource Loaded Cost & Schedule (Final) Complete | milestone | 0d | 2004-04-30 A | 2004-04-30 A | 100% |  | 2004-04-30 | 2004-04-30 | 0d |  | finish no later than 2004-04-30 | PM | ML3 | MS3_PM031 | apm/dd |
| 45 | 3.1.3 | 1st Monthly Report (with Earned Value) Submitted | milestone | 0d | 2004-04-30 A | 2004-04-30 A | 100% |  | 2004-04-30 | 2004-04-30 | 0d |  | finish no later than 2004-04-30 | PM | ML3 | MS3_PM035 |  |
| 46 | 3.1.4 | Risk Management Plan Complete | milestone | 0d | 2004-04-30 A | 2004-04-30 A | 100% |  | 2004-04-30 | 2004-04-30 | 0d |  | as late as possible | PM | ML3 | MS3_PM042 |  |
| 47 | 3.1.5 | Prelim Safety Assessment Doc (PSAD) Submitted | milestone | 0d | 2004-04-30 A | 2004-04-30 A | 100% |  | 2004-04-30 | 2004-04-30 | 0d |  | finish no later than 2004-04-30 | PM | ML3 | MS3_PM045 |  |
| 48 | 3.1.6 | Project Mgmt Control Syst (PMCS) Review Complete | milestone | 0d | 2004-04-30 A | 2004-04-30 A | 100% |  | 2004-04-30 | 2004-04-30 | 0d |  | finish no later than 2004-04-30 | PM | ML3 | MS3_PM050 | apm/dd |
| 49 | 3.1.7 | Project Mgmt Plan Complete | milestone | 0d | 2004-04-30 A | 2004-04-30 A | 100% |  | 2004-04-30 | 2004-04-30 | 0d |  | finish no later than 2004-04-30 | PM | ML3 | MS3_PM055 |  |
| 50 | 3.1.8 | CRIT: Start Procurement Package - PMCS Support | milestone | 0d | 2004-10-01 A | 2004-10-01 A | 100% |  | 2004-10-01 | 2004-10-01 | 0d |  | finish no later than 2004-10-01 | PM | ML3 | MSC_PM000 |  |
| 51 | 3.1.9 | Fire Hazard Analysis Review @ SLAC | milestone | 0d | 2005-07-15 A | 2005-07-15 A | 100% |  | 2005-04-29 | 2005-06-10 | 0d |  | finish no earlier than 2005-07-15 | PM | ML3 | MS3_PM040 |  |
| 52 | 3.1.10 | FY05 Shutdown: HW Reqd for Installation | milestone | 0d | 2005-10-03 A | 2005-10-03 A | 100% |  | 2005-10-03 | 2005-10-03 | 0d |  | finish no earlier than 2005-10-03 | PM | ML3 | MSBS_115 |  |
| 53 | 3.1.11 | FY05 Shutdown Over | milestone | 0d | 2005-10-31 A | 2005-10-31 A | 100% |  | 2005-10-31 | 2005-10-31 | 0d |  | finish no earlier than 2005-10-31 | PM | ML3 | MSBS_120 |  |
| 54 | 3.1.12 | FY06 Shutdown: HW Reqd for Installation | milestone | 0d | 2006-08-21 | 2006-08-21 |  |  | 2006-08-01 | 2006-08-01 | 0d | 945d | finish no earlier than 2006-08-21 | PM | ML3 | MSBS_125 |  |
| 55 | 3.1.13 | FY06 Shutdown Over | milestone | 0d | 2007-03-29 | 2007-03-29 |  |  | 2006-11-30 | 2007-01-05 | 0d | 796d | finish no earlier than 2007-03-29 | PM | ML3 | MSBS_130 | apm/dd |
| 56 | 3.1.14 | FY07 Shutdown: HW Reqd for Installation | milestone | 0d | 2007-09-04 | 2007-09-04 |  |  | 2007-09-04 | 2007-09-04 | 0d | 683d | finish no earlier than 2007-09-04 | PM | ML3 | MSBS_135 |  |
| 57 | 3.1.15 | FY07 Shutdown Over | milestone | 0d | 2007-12-03 | 2007-12-03 |  |  | 2007-11-30 | 2007-11-30 | 0d | 619d | finish no earlier than 2007-12-03 | PM | ML3 | MSBS_140 |  |
| 58 | 3.1.16 | LCLS ARR Complete | milestone | 0d | 2009-01-08 | 2009-01-08 |  |  | 2008-05-09 | 2008-06-12 | 0d | 351d | finish no earlier than 2009-01-08 | PM | ML3 | MS3_PM030 |  |
| 59 | 3.1.17 | Start FY08 Shutdown | milestone | 0d | 2008-10-01 | 2008-10-01 |  |  | 2008-06-02 | 2008-09-12 | 0d | 411d | finish no earlier than 2008-10-01 | PM | ML3 | MSBS_145 |  |
| 60 | 3.1.18 | FY08 Shutdown Over | milestone | 0d | 2008-11-03 | 2008-11-03 |  |  | 2008-08-29 | 2009-01-02 | 0d | 388d | finish no earlier than 2008-11-03 | PM | ML3 | MSBS_150 |  |
| 61 | 3.2 | **Injector System (WBS 1.02)** |  | 1031d | 2004-10-15 | 2008-11-21 |  |  | 2004-10-15 | 2007-11-26 | 780d | 374d |  |  |  |  |  |
| 62 | 3.2.1 | CRIT: Release RFP for Drive Laser | milestone | 0d | 2004-10-15 | 2004-10-15 |  |  | 2005-05-17 | 2004-10-15 | 0d | 1405d | finish no earlier than 2004-10-15 | IJ | ML3 | MSC_IJ000 |  |
| 63 | 3.2.2 | Award of Drive Laser Contract Complete | milestone | 0d | 2005-06-30 | 2005-06-30 |  |  | 2005-05-17 | 2005-06-30 | 0d | 1232d | finish no earlier than 2005-06-30 | IJ | ML3 | MS3_IJ095 |  |
| 64 | 3.2.3 | Laser Tables & Optical Paths Installation Comp | milestone | 0d | 2006-08-01 | 2006-08-01 |  |  | 2006-08-21 | 2006-08-21 | 0d | 959d | finish no earlier than 2006-08-01 | IJ | ML3 | MS3_IJ032 | apm/dd |
| 65 | 3.2.4 | Drive Laser Available for Integration | milestone | 0d | 2006-11-30 | 2006-11-30 |  |  | 2006-05-19 | 2006-11-16 | 0d | 872d | finish no earlier than 2006-11-30 | IJ | ML3 | MS3_IJ005 |  |
| 66 | 3.2.5 | Start Injector Commissioning (Drive Laser) | milestone | 0d | 2007-01-16 | 2007-01-16 |  |  | 2006-10-18 | 2006-12-14 | 0d | 848d | finish no earlier than 2007-01-16 | IJ | ML3 | MS3_IJ0010 | apm/dd |
| 67 | 3.2.6 | Injector Laser Commissioning Review Complete | milestone | 0d | 2006-11-30 | 2006-11-30 |  |  | 2006-08-18 | 2006-12-14 | 0d | 872d | finish no earlier than 2006-11-30 | IJ | ML3 | MS3_IJ0027 |  |
| 68 | 3.2.7 | Injector Accelerator Readiness Review (ARR) Comp | milestone | 0d | 2007-03-30 | 2007-03-30 |  |  | 2007-04-20 | 2006-12-15 | 0d | 795d | finish no earlier than 2007-03-30 | IJ | ML3 | MS3_IJ0030 | apm/dd |
| 69 | 3.2.8 | Accelerator Region Installation Complete | milestone | 0d | 2006-12-30 | 2006-12-30 |  |  | 2006-07-18 | 2007-01-29 | 0d | 858d | finish no earlier than 2006-12-30 | IJ | ML3 | MS3_IJ085 |  |
| 70 | 3.2.9 | Gun Region Installation Complete | milestone | 0d | 2007-03-30 | 2007-03-30 |  |  | 2006-08-18 | 2007-01-29 | 0d | 795d | finish no earlier than 2007-03-30 | IJ | ML3 | MS3_IJ080 | apm/dd |
| 71 | 3.2.10 | Injector RF Subsystem Installation Complete | milestone | 0d | 2007-03-30 | 2007-03-30 |  |  | 2007-03-28 | 2007-01-31 | 0d | 795d | finish no earlier than 2007-03-30 | IJ | ML3 | MS3_IJ110 | apm/dd |
| 72 | 3.2.11 | Injector Controls Installation Complete | milestone | 0d | 2007-03-16 | 2007-03-16 |  |  | 2007-10-19 | 2007-01-02 | 0d | 805d | finish no earlier than 2007-03-16 | CT | ML3 | MS3_CT070 | apm/dd |
| 73 | 3.2.12 | Spectrometer Installation Complete | milestone | 0d | 2007-03-30 | 2007-03-30 |  |  | 2006-10-27 | 2007-02-02 | 0d | 795d | finish no earlier than 2007-03-30 | IJ | ML3 | MS3_IJ105 | apm/dd |
| 74 | 3.2.13 | RF Gun Ready for Installation | milestone | 0d | 2006-12-01 | 2006-12-01 |  |  | 2006-08-11 | 2007-02-15 | 0d | 871d | finish no earlier than 2006-12-01 | IJ | ML3 | MS3_IJ125 |  |
| 75 | 3.2.14 | Insertion Region Installation Complete | milestone | 0d | 2006-12-30 | 2006-12-30 |  |  | 2006-10-27 | 2007-02-08 | 0d | 858d | finish no earlier than 2006-12-30 | IJ | ML3 | MS3_IJ100 | apm/dd |
| 76 | 3.2.15 | Start Injector Commissioning(UV Beam to Cathode) | milestone | 0d | 2007-04-05 | 2007-04-05 |  |  | 2007-06-20 | 2007-03-06 | 0d | 791d | finish no earlier than 2007-04-05 | IJ | ML3 | MS3_IJ0020 | apm/dd |
| 77 | 3.2.16 | Laser Heater Installation Complete | milestone | 0d | 2008-11-21 | 2008-11-21 |  |  | 2007-11-26 | 2008-01-02 | 0d | 374d | finish no earlier than 2008-11-21 | IJ | ML3 | MS3_IJ120 | apm/dd |

| ID | WBS | Task | Type | Duration | Start | Finish | Complete | Remaining | Baseline start | Baseline finish | Baseline duration | Total slack | Constraint | Text1 | Text10 | Text11 |
| --- | --- | --- | --- | --- | --- | --- | --- | --- | --- | --- | --- | --- | --- | --- | --- | --- |
| 78 | 3.3 | **Linac System (WBS 1.03)** |  | 970d | 2005-02-25 | 2009-01-08 |  |  | 2005-04-13 | 2008-06-09 | 791d | 351d |  |  |  |  |
| 79 | 3.3.1 | CRIT: Release RFP X-Band Klystron | milestone | 0d | 2005-02-25 | 2005-02-25 |  |  | 2005-04-13 | 2005-02-25 | 0d | 1321d | finish no earlier than 2005-02-25 | LN | ML3 | MSC_LN005 |
| 80 | 3.3.2 | Shutdown of FFTB Operations | milestone | 0d | 2006-04-10 | 2006-04-10 |  |  | 2006-06-01 | 2006-06-01 | 0d | 1040d | finish no earlier than 2006-04-10 | LN | ML3 | MSBS_090 |
| 81 | 3.3.3 | BC1 Bend Magnet Ready for Installation | milestone | 0d | 2006-09-29 | 2006-09-29 |  |  | 2006-07-03 | 2006-11-13 | 0d | 916d | finish no earlier than 2006-09-29 | LN | ML3 | MS3_LN016 |
| 82 | 3.3.4 | X-Band Klystron Ready for Installation | milestone | 0d | 2006-08-31 | 2006-08-31 |  |  | 2006-11-22 | 2006-11-27 | 0d | 937d | finish no earlier than 2006-08-31 | LN | ML3 | MS3_LN010 |
| 83 | 3.3.5 | BC1 Installation Complete | milestone | 0d | 2007-01-31 | 2007-01-31 |  |  | 2006-11-29 | 2007-01-29 | 0d | 837d | finish no earlier than 2007-01-31 | LN | ML3 | MS3_LN012 |
| 84 | 3.3.6 | Linac Controls Ready for BC1 Installation | milestone | 0d | 2007-03-16 | 2007-03-16 |  |  | 2008-03-18 | 2007-01-31 | 0d | 805d | finish no earlier than 2007-03-16 | CT | ML3 | MS3_CT072 |
| 85 | 3.3.7 | Start BC1 Commissioning | milestone | 0d | 2007-03-30 | 2007-03-30 |  |  | 2006-11-29 | 2007-02-28 | 0d | 795d | finish no earlier than 2007-03-30 | LN | ML3 | MS3_LN013 |
| 86 | 3.3.8 | Linac Commissioning Review Complete - S20-30 | milestone | 0d | 2008-01-03 | 2008-01-03 |  |  | 2006-10-03 | 2007-11-05 | 0d | 604d | finish no earlier than 2008-01-03 | LN | ML3 | MS3_LN030 |
| 87 | 3.3.9 | BC2 Installation Complete | milestone | 0d | 2008-01-02 | 2008-01-02 |  |  | 2008-01-30 | 2008-01-02 | 0d | 604d | finish no earlier than 2008-01-02 | LN | ML3 | MS3_LN011 |
| 88 | 3.3.10 | Start Linac (Li20-Li30) Commissioning | milestone | 0d | 2008-01-07 | 2008-01-07 |  |  | 2008-02-04 | 2008-02-01 | 0d | 603d | finish no earlier than 2008-01-07 | LN | ML3 | MS3_LN025 |
| 89 | 3.3.11 | E-Dump Component Installation Complete | milestone | 0d | 2008-08-15 | 2008-08-15 |  |  | 2008-04-25 | 2008-03-26 | 0d | 444d | finish no earlier than 2008-08-15 | LN | ML3 | MS3_LN055 |
| 90 | 3.3.12 | LTU Component Installation Complete | milestone | 0d | 2008-10-03 | 2008-10-03 |  |  | 2008-05-07 | 2008-03-26 | 0d | 409d | finish no earlier than 2008-10-03 | LN | ML3 | MS3_LN035 |
| 91 | 3.3.13 | Linac Commissioning Review Complete - LTU | milestone | 0d | 2009-01-07 | 2009-01-07 |  |  | 2008-03-07 | 2008-03-31 | 0d | 352d | finish no earlier than 2009-01-07 | LN | ML3 | MS3_LN032 |
| 92 | 3.3.14 | Start Linac-to-Undulator (LTU) Commissioning | milestone | 0d | 2009-01-08 | 2009-01-08 |  |  | 2008-05-09 | 2008-06-30 | 0d | 351d | finish no earlier than 2009-01-08 | LN | ML3 | MS3_LN015 |
| 93 | 3.4 | **Undulator System (WBS 1.04)** |  | 1062d | 2005-01-14 A | 2009-04-06 |  | 1062d | 2005-01-14 | 2008-08-18 | 904d | 289d |  |  |  |  |
| 94 | 3.4.1 | CRIT: Release RFP Ti Strongback | milestone | 0d | 2005-01-14 A | 2005-01-14 A | 100% |  | 2005-01-14 | 2005-01-14 | 0d |  | finish no earlier than 2005-01-14 | UN | ML3 | MSC_UN005 |
| 95 | 3.4.2 | CRIT: Release RFP Magnet Poles | milestone | 0d | 2005-02-04 | 2005-02-04 |  |  | 2005-03-22 | 2005-02-04 | 0d | 1336d | finish no earlier than 2005-02-04 | UN | ML3 | MSC_UN015 |
| 96 | 3.4.3 | CRIT: Release RFP Magnet Blocks | milestone | 0d | 2005-03-23 | 2005-03-23 |  |  | 2005-04-13 | 2005-03-23 | 0d | 1303d | finish no earlier than 2005-03-23 | UN | ML3 | MSC_UN010 |
| 97 | 3.4.4 | CRIT: Release RFP Magnet Assemblies - 1st Art | milestone | 0d | 2005-06-28 | 2005-06-28 |  |  | 2005-04-14 | 2005-06-28 | 0d | 1234d | finish no earlier than 2005-06-28 | UN | ML3 | MSC_UN020 |
| 98 | 3.4.5 | Award of 1st Articles Mag Assy to Vendors Comp | milestone | 0d | 2005-10-04 | 2005-10-04 |  |  | 2005-08-09 | 2005-10-11 | 0d | 1164d | finish no earlier than 2005-10-04 | UN | ML3 | MS3_UN028 |
| 99 | 3.4.6 | CRIT: Release RFP - Quadrupoles | milestone | 0d | 2006-06-14 | 2006-06-14 |  |  | 2006-02-28 | 2006-04-12 | 0d | 993d | finish no earlier than 2006-06-14 | UN | ML3 | MSC_UN016 |
| 100 | 3.4.7 | Undulator SUT Completed | milestone | 0d | 2006-07-19 | 2006-07-19 |  |  | 2006-04-28 | 2006-04-28 | 0d | 968d | finish no earlier than 2006-07-19 | UN | ML3 | MS3_UN018 |
| 101 | 3.4.8 | CRIT: Release RFP - Fixed Supports | milestone | 0d | 2006-05-09 | 2006-05-09 |  |  | 2005-10-17 | 2006-05-09 | 0d | 1019d | finish no earlier than 2006-05-09 | UN | ML3 | MSC_UN030 |
| 102 | 3.4.9 | 1st Article Vendor A Undulator 1 Rcvd @ SLAC | milestone | 0d | 2006-03-30 | 2006-03-30 |  |  | 2006-06-02 | 2006-06-02 | 0d | 1047d | finish no earlier than 2006-03-30 | UN | ML3 | MS3_UN006 |
| 103 | 3.4.10 | 1st Article Vendor B Undulator 2 Rcvd @ SLAC | milestone | 0d | 2006-06-15 | 2006-06-15 |  |  | 2006-06-02 | 2006-06-02 | 0d | 992d | finish no earlier than 2006-06-15 | UN | ML3 | MS3_UN010 |
| 104 | 3.4.11 | MMF Qualified & Ready to Measure Prod Undulators | milestone | 0d | 2006-08-28 | 2006-08-28 |  |  | 2006-07-28 | 2006-10-27 | 0d | 940d | finish no earlier than 2006-08-28 | UN | ML3 | MS3_UN005 |
| 105 | 3.4.12 | 25% production undulators received | milestone | 0d | 2006-08-28 | 2006-08-28 |  |  | 2006-07-28 | 2007-01-02 | 0d | 940d | finish no earlier than 2006-08-28 | UN | ML3 | MS3_UN015 |
| 106 | 3.4.13 | 50% production undulators received | milestone | 0d | 2006-12-21 | 2006-12-21 |  |  | 2006-10-17 | 2007-03-19 | 0d | 858d | finish no earlier than 2006-12-21 | UN | ML3 | MS3_UN022 |
| 107 | 3.4.14 | 75% production undulators received | milestone | 0d | 2007-01-31 | 2007-01-31 |  |  | 2007-01-03 | 2007-06-07 | 0d | 837d | finish no earlier than 2007-01-31 | UN | ML3 | MS3_UN027 |
| 108 | 3.4.15 | Undulator Production Units (33) Received | milestone | 0d | 2007-04-30 | 2007-04-30 |  |  | 2007-03-09 | 2007-07-06 | 0d | 774d | finish no earlier than 2007-04-30 | UN | ML3 | MS3_UN029 |
| 109 | 3.4.16 | Hydrostatic Level System Complete | milestone | 0d | 2008-08-08 | 2008-08-08 |  |  | 2007-03-02 | 2008-05-28 | 0d | 449d | finish no earlier than 2008-08-08 | UN | ML3 | MS3_UN040 |
| 110 | 3.4.17 | Undulator Controls Ready for Commissioning | milestone | 0d | 2008-04-28 | 2008-04-28 |  |  | 2007-03-02 |  | 0d | 523d | finish no earlier than 2008-04-28 | UN | ML3 | MS3_CT085 |
| 111 | 3.4.18 | Wire Monitoring System Complete | milestone | 0d | 2008-08-08 | 2008-08-08 |  |  | 2008-03-07 | 2008-05-28 | 0d | 449d | finish no earlier than 2008-08-08 | UN | ML3 | MS3_UN042 |
| 112 | 3.4.19 | Undulator System Installation Complete | milestone | 0d | 2008-11-14 | 2008-11-14 |  |  | 2008-07-18 | 2008-05-28 | 0d | 379d | finish no earlier than 2008-11-14 | UN | ML3 | MS3_UN020 |
| 113 | 3.4.20 | 1st Production Vacuum Chamber Delivered to SLAC | milestone | 0d | 2008-01-02 | 2008-01-02 |  |  | 2008-07-18 |  | 0d | 604d | finish no earlier than 2008-01-02 | UN | ML3 | MS3_UN030 |
| 114 | 3.4.21 | 1st Production RFBPM Delivered to SLAC | milestone | 0d | 2008-04-04 | 2008-04-04 |  |  | 2008-07-18 |  | 0d | 539d | finish no earlier than 2008-04-04 | UN | ML3 | MS3_UN035 |
| 115 | 3.4.22 | 1st Production BFW Delivered to SLAC | milestone | 0d | 2007-11-17 | 2007-11-17 |  |  | 2008-07-18 |  | 0d | 630d | finish no earlier than 2007-11-17 | UN | ML3 | MS3_UN045 |
| 116 | 3.4.23 | Start Undulator Commissioning (1st Light) | milestone | 0d | 2009-04-06 | 2009-04-06 |  |  | 2008-07-18 | 2008-07-18 | 0d | 289d | finish no earlier than 2009-04-06 | UN | ML3 | MS3_UN025 |

| ID | WBS | Task | Type | Duration | Start | Finish | Baseline start | Baseline finish | Baseline duration | Total slack | Constraint | Text1 | Text10 | Text11 |
| --- | --- | --- | --- | --- | --- | --- | --- | --- | --- | --- | --- | --- | --- | --- |
| 117 | 3.5 | **X-Ray Transport & Diagnostics (WBS 1.05)** |  | 824d | 2006-11-14 | 2010-03-08 | 2006-06-07 | 2008-09-15 | 571d | 60d |  |  |  |  |
| 118 | 3.5.1 | Tunnel Mech/Vac Design Review Complete | milestone | 0d | 2006-11-14 | 2006-11-14 | 2007-10-26 | 2006-11-29 | 0d | 884d | finish no earlier than 2006-11-14 | XTOD | ML3 | MS3_XT007 |
| 119 | 3.5.2 | Fixed Mask Ready to Ship to SLAC | milestone | 0d | 2007-12-14 | 2007-12-14 | 2007-09-10 | 2007-07-30 | 0d | 610d | finish no earlier than 2007-12-14 | XTOD | ML3 | MS3_XT030 |
| 120 | 3.5.3 | AWARD: LE Mirror Substrate | milestone | 0d | 2007-07-31 | 2007-07-31 | 2007-09-10 |  | 0d | 708d | finish no earlier than 2007-07-31 | XTOD | ML3 | MS3_XT040 |
| 121 | 3.5.4 | AWARD: HE Mirror Substrate | milestone | 0d | 2007-11-16 | 2007-11-16 | 2007-09-10 |  | 0d | 630d | finish no earlier than 2007-11-16 | XTOD | ML3 | MS3_XT060 |
| 122 | 3.5.5 | Gas/Solid Attenuator Ready to Ship to SLAC | milestone | 0d | 2008-02-15 | 2008-02-15 | 2007-06-12 | 2007-10-29 | 0d | 574d | finish no earlier than 2008-02-15 | XTOD | ML3 | MS3_XT025 |
| 123 | 3.5.6 | XT Start FEE Installation | milestone | 0d | 2008-08-21 | 2008-08-21 | 2007-07-23 | 2007-12-04 | 0d | 440d | finish no earlier than 2008-08-21 | XTOD | ML3 | MS3_XT100 |
| 124 | 3.5.7 | XT Start Tunnel Installation | milestone | 0d | 2009-07-13 | 2009-07-13 | 2007-07-23 |  | 0d | 219d | finish no earlier than 2009-07-13 | XTOD | ML3 | MS3_XT050 |
| 125 | 3.5.8 | XT Tunnel/FEH Install/Check Complete | milestone | 0d | 2010-01-11 | 2010-01-11 | 2008-09-15 | 2008-05-13 | 0d | 100d | finish no earlier than 2010-01-11 | XTOD | ML3 | MS3_XT071 |
| 126 | 3.5.9 | FEE Install/Check Complete | milestone | 0d | 2009-02-09 | 2009-02-09 | 2008-05-02 | 2008-08-14 | 0d | 329d | finish no earlier than 2009-02-09 | XTOD | ML3 | MS3_XT000 |
| 127 | 3.5.10 | Start FEE Commissioning with Beam | milestone | 0d | 2009-04-06 | 2009-04-06 | 2008-09-15 | 2008-09-08 | 0d | 289d | finish no earlier than 2009-04-06 | XTOD | ML3 | MS3_XT005 |
| 128 | 3.5.11 | First X-Rays into FEH | milestone | 0d | 2010-03-08 | 2010-03-08 | 2008-03-04 |  | 0d | 60d | finish no earlier than 2010-03-08 | XTOD | ML3 | MS3_XT075 |
| 129 | 3.6 | **X-Ray Endstations (WBS 1.06)** |  | 1184d? | 2005-05-16 | 2010-02-05 | 2004-12-01 | 2009-01-20 | 1025d | 81d |  |  |  |  |
| 130 | 3.6.1 | Complete 2-D X-Ray Detector Statement of Work | milestone | 0d | 2005-05-16 | 2005-05-16 | 2004-12-01 | 2005-07-01 | 0d | 1265d | finish no earlier than 2005-05-16 | XE | ML3 | MS3_XE030 |
| 131 | 3.6.2 | Award Initial Funding for 2-D X-Ray Detector | milestone | 0d | 2005-07-15 | 2005-07-15 | 2005-03-11 | 2005-07-15 | 0d | 1221d | finish no earlier than 2005-07-15 | XE | ML3 | MS3_XE035 |
| 132 | 3.6.3 | Hire Atomic Physicist | milestone | 0d | 2006-01-03 | 2006-01-03 | 2009-01-20 | 2006-03-17 | 0d | 1108d | finish no earlier than 2006-01-03 | XE | ML3 | MS3_XE110 |
| 133 | 3.6.4 | Hire Detector Physicist | milestone | 0d | 2006-01-17 | 2006-01-17 | 2009-01-20 | 2006-04-03 | 0d | 1099d | finish no earlier than 2006-01-17 | XE | ML3 | MS3_XE100 |
| 134 | 3.6.5 | LDAC Mid-Project Review (2D Detector) | milestone | 0d | 2007-11-30 | 2007-11-30 | 2006-11-20 | 2007-03-19 | 0d | 620d | finish no earlier than 2007-11-30 | XE | ML3 | MS3_XE040 |
| 135 | 3.6.6 | COMP: AMO PDR Meeting | milestone | 0d | 2007-08-31 | 2007-08-31 | 2006-11-20 |  | 0d | 685d | finish no earlier than 2007-08-31 | XE | ML3 | MS3_XE020 |
| 136 | 3.6.7 | Award XES Laser System | milestone | 0d | 2008-03-20 | 2008-03-20 | 2007-08-10 | 2007-10-04 | 0d | 550d | finish no earlier than 2008-03-20 | XE | ML3 | MS3_XE025 |
| 137 | 3.6.8 | FEE/NEH PPS Certified | milestone | 0d | 2009-02-23 | 2009-02-23 | 2009-01-20 | 2007-10-04 | 0d | 319d | finish no earlier than 2009-02-23 | XE | ML3 | MS3_XE130 |
| 138 | 3.6.9 | TUN/FEH PPS Certified | milestone | 0d | 2010-02-05 | 2010-02-05 | 2009-01-20 |  | 0d | 81d | finish no earlier than 2010-02-05 | XE | ML3 | MS3_XE150 |
| 139 | 3.6.10 | 2-D Detector Shipped to SLAC | milestone | 0d | 2009-02-13 | 2009-02-13 | 2007-12-03 | 2007-11-05 | 0d | 325d | finish no earlier than 2009-02-13 | XE | ML3 | MS3_XE015 |
| 140 | 3.6.11 | XE Start Installation in FEH | milestone | 0d | 2009-08-03 | 2009-08-03 | 2007-09-04 | 2008-08-20 | 0d | 204d | finish no earlier than 2009-08-03 | XE | ML3 | MS3_XE050 |
| 141 | 3.6.12 | Electron Dump Stoppers Certified | milestone | 1d? | 2009-01-08 | 2009-01-08 |  | 2008-03-25 |  | 351d | finish no earlier than 2009-01-08 | XE | ML3 | MS3_XE120 |
| 142 | 3.6.13 | XE Start Installation in NEH | milestone | 1d? | 2008-08-18 | 2008-08-18 |  | 2008-04-16 |  | 443d | finish no earlier than 2008-08-18 | XE | ML3 | MS3_XE060 |
| 143 | 3.6.14 | First X-Rays into NEH | milestone | 0d | 2009-06-15 | 2009-06-15 | 2008-03-04 | 2008-09-02 | 0d | 239d | finish no earlier than 2009-06-15 | XE | ML3 | MS3_XE005 |
| 144 | 3.6.15 | XES Laser Operating in Near Hall | milestone | 0d | 2008-11-24 | 2008-11-24 | 2008-04-22 | 2008-09-19 | 0d | 373d | finish no earlier than 2008-11-24 | XE | ML3 | MS3_XE080 |
| 145 | 3.6.16 | AMO Experiment for Basic Expmnts (CD4a) | milestone | 0d | 2009-01-26 | 2009-01-26 | 2008-07-08 |  | 0d | 339d | finish no earlier than 2009-01-26 | XE | ML3 | MS3_XE065 |

| ID | WBS | Task | Type | Duration | Start | Finish | Complete | Remaining | Baseline start | Baseline finish | Baseline duration | Total slack | Constraint | Text1 | Text10 | Text11 |
| --- | --- | --- | --- | --- | --- | --- | --- | --- | --- | --- | --- | --- | --- | --- | --- | --- |
| 146 | 3.7 | **Conventional Facilities (WBS 1.09)** |  | 1309d? | 2004-04-30 A | 2009-07-16 |  | 1309d? | 2004-04-30 | 2008-11-10 | 1138d | 216d |  |  |  |  |
| 147 | 3.7.1 | A&E Serv (S20, MMF, MCC not incl) Title 1 Comp | milestone | 0d | 2004-04-30 A | 2004-04-30 A | 100% |  | 2004-04-30 | 2004-04-30 | 0d |  | finish no earlier than 2004-04-30 | CF | ML3 | MS3_CF000 |
| 148 | 3.7.2 | A&E Serv Sector 20 Title 1 Complete | milestone | 0d | 2004-04-30 A | 2004-04-30 A | 100% |  | 2004-04-30 | 2004-04-30 | 0d |  | finish no earlier than 2004-04-30 | CF | ML3 | MS3_CF002 |
| 149 | 3.7.3 | A&E Services MMF Title 1 Complete | milestone | 0d | 2004-04-30 A | 2004-04-30 A | 100% |  | 2004-04-30 | 2004-04-30 | 0d |  | finish no earlier than 2004-04-30 | CF | ML3 | MS3_CF022 |
| 150 | 3.7.4 | CRIT: Rel RFP T3 Const. Pkg. RF Hut & S20/Alcove | milestone | 0d | 2005-04-01 A | 2005-04-01 A | 100% |  | 2005-03-01 | 2005-04-01 | 0d |  | finish no earlier than 2005-04-01 | CF | ML3 | MSC_CF005 |
| 151 | 3.7.5 | A&E Services Sector 20 Title 2 Complete | milestone | 0d | 2005-03-18 A | 2005-03-18 A | 100% |  | 2005-03-18 | 2005-03-18 | 0d |  | finish no earlier than 2005-03-18 | CF | ML3 | MS3_CF010 |
| 152 | 3.7.6 | CRIT: Release RFP T3 Construction Contract (MMF) | milestone | 0d | 2005-04-14 A | 2005-04-14 A | 100% |  | 2005-03-24 | 2005-04-14 | 0d |  | finish no earlier than 2005-04-14 | CF | ML3 | MSC_CF010 |
| 153 | 3.7.7 | A&E Services MMF Title 2 Complete | milestone | 0d | 2005-05-31 A | 2005-05-31 A | 100% |  | 2005-05-31 | 2005-05-31 | 0d |  | finish no earlier than 2005-05-31 | CF | ML3 | MS3_CF015 |
| 154 | 3.7.8 | CRIT: Release RFP Constructrion Mgmt Pkg (CM) | milestone | 0d | 2005-07-25 A | 2005-07-25 A | 100% |  | 2006-01-24 | 2005-07-25 | 0d |  | finish no earlier than 2005-07-25 | CF | ML3 | MSC_CF020 |
| 155 | 3.7.9 | Award of Sector 20 Title 3 Complete | milestone | 0d | 2005-07-28 A | 2005-07-28 A | 100% |  | 2005-08-05 | 2005-08-05 | 0d |  | finish no earlier than 2005-07-28 | CF | ML3 | MS3_CF065 |
| 156 | 3.7.10 | Award of Magnetic Msmt Facility Title 3 Complete | milestone | 0d | 2005-07-28 A | 2005-07-28 A | 100% |  | 2005-08-05 | 2005-08-05 | 0d |  | finish no earlier than 2005-07-28 | CF | ML3 | MS3_CF066 |
| 157 | 3.7.11 | Award of Construction Management Package - Ph.1 | milestone | 0d | 2005-10-17 A | 2005-10-17 A | 100% |  | 2005-08-30 | 2005-09-30 | 0d |  | finish no earlier than 2005-10-17 | CF | ML3 | MS3_CF060 |
| 158 | 3.7.12 | RF Hut Beneficial Occupancy | milestone | 0d | 2006-03-09 A | 2006-03-09 A | 100% |  | 2005-12-07 | 2005-12-07 | 0d |  | finish no earlier than 2006-03-09 | CF | ML3 | MSBO_000 |
| 159 | 3.7.13 | A&E Serv (S20, MMF, MCC not incl) Title 2 Comp | milestone | 0d | 2006-02-28 A | 2006-02-28 A | 100% |  | 2006-01-20 | 2006-01-20 | 0d |  | finish no earlier than 2006-02-28 | CF | ML3 | MS3_CF005 |
| 160 | 3.7.14 | CRIT: Release RFP T3 Construct (RY-CLOC) | milestone | 0d | 2006-03-08 A | 2006-03-08 A | 100% |  | 2005-09-06 | 2006-01-26 | 0d |  | finish no earlier than 2006-03-08 | CF | ML3 | MSC_CF000 |
| 161 | 3.7.15 | Magnetic Msmt Facility(MMF) Beneficial Occupancy | milestone | 0d | 2006-03-29 A | 2006-03-29 A | 100% |  | 2006-04-03 | 2006-04-03 | 0d |  | finish no earlier than 2006-03-29 | CF | ML3 | MSBO_010 |
| 162 | 3.7.16 | Sector 20 Alcove Beneficial Occupancy | milestone | 0d | 2006-04-14 A | 2006-04-14 A | 100% |  | 2006-06-21 | 2006-06-21 | 0d |  | finish no earlier than 2006-04-14 | CF | ML3 | MS3BO_005 |
| 163 | 3.7.17 | CRIT: Release RFP T3 Construction Pkg (Linac) | milestone | 0d | 2006-07-31 | 2006-07-31 |  |  | 2006-01-24 | 2006-07-10 | 0d | 960d | finish no earlier than 2006-07-31 | CF | ML3 | MSC_CF006 |
| 164 | 3.7.18 | Research Yards Mods Beneficial Occupancy | milestone | 0d | 2006-08-30 A | 2006-08-30 A | 100% |  | 2006-09-21 | 2006-09-21 | 0d |  | finish no earlier than 2006-08-30 | CF | ML3 | MS3BO_025 |
| 165 | 3.7.19 | Undulator Facility Beneficial Occupancy | milestone | 0d | 2008-03-20 | 2008-03-20 |  |  | 2007-05-03 | 2008-03-20 | 0d | 550d | finish no earlier than 2008-03-20 | CF | ML3 | MS3BO_035 |
| 166 | 3.7.20 | Near Experimental Hall Beneficial Occupancy | milestone | 0d | 2008-03-20 | 2008-03-20 |  |  | 2007-05-18 | 2008-03-20 | 0d | 550d | finish no earlier than 2008-03-20 | CF | ML3 | MS3BO_050 |
| 167 | 3.7.21 | Front End Enclosure Beneficial Occupancy | milestone | 0d | 2008-03-20 | 2008-03-20 |  |  | 2007-09-05 | 2008-03-20 | 0d | 550d | finish no earlier than 2008-03-20 | CF | ML3 | MS3BO_040 |
| 168 | 3.7.22 | Beam Dump Beneficial Occupancy | milestone | 0d | 2008-03-20 | 2008-03-20 |  |  | 2007-10-09 | 2008-03-20 | 0d | 550d | finish no earlier than 2008-03-20 | CF | ML3 | MSBO_045 |
| 169 | 3.7.23 | Central Utility Plant Beneficial Occupancy | milestone | 1d? | 2008-03-20 | 2008-03-20 |  |  |  | 2008-03-20 |  | 550d | finish no earlier than 2008-03-20 | CF | ML3 | MS3BO_065 |
| 170 | 3.7.24 | Beam Transport Hall Beneficial Occupancy | milestone | 0d | 2008-03-20 | 2008-03-20 |  |  | 2007-12-03 | 2008-03-20 | 0d | 550d | finish no earlier than 2008-03-20 | CF | ML3 | MS3BO_030 |
| 171 | 3.7.25 | Far Experimental Hall Co-Occupancy | milestone | 1d? | 2008-03-21 | 2008-03-21 |  |  |  | 2008-03-21 |  | 549d | finish no earlier than 2008-03-21 | CF | ML3 | MS3CO_030 |
| 172 | 3.7.26 | CEH Building Beneficial Occupancy | milestone | 1d? | 2009-07-16 | 2009-07-16 |  |  |  | 2008-04-26 |  | 216d | finish no earlier than 2009-07-16 | CF | ML3 | MS3BO_070 |
| 173 | 3.7.27 | Linac Power/Water Available | milestone | 0d | 2007-03-29 | 2007-03-29 |  |  | 2007-06-11 | 2007-06-11 | 0d | 796d | finish no earlier than 2007-03-29 | CF | ML3 | MS3BO_020 |
| 174 | 3.7.28 | Far Experimental Hall Beneficial Occupancy | milestone | 0d | 2008-06-20 | 2008-06-20 |  |  | 2007-08-03 | 2008-06-20 | 0d | 484d | finish no earlier than 2008-06-20 | CF | ML3 | MS3BO_060 |
| 175 | 3.7.29 | Front End Enclosure Co-Occupancy | milestone | 1d? | 2007-12-04 | 2007-12-04 |  |  |  | 2007-12-04 |  | 618d | finish no earlier than 2007-12-04 | CF | ML3 | MS3CO_015 |
| 176 | 3.7.30 | Beam Transport Hall Co-Occupancy | milestone | 1d? | 2007-12-04 | 2007-12-04 |  |  |  | 2007-12-04 |  | 618d | finish no earlier than 2007-12-04 | CF | ML3 | MS3CO_005 |
| 177 | 3.7.31 | Undulator Facility Co-Occupancy | milestone | 1d? | 2007-12-04 | 2007-12-04 |  |  |  | 2007-12-04 |  | 618d | finish no earlier than 2007-12-04 | CF | ML3 | MS3CO_010 |
| 178 | 3.7.32 | Beam Dump Co-Occupancy | milestone | 1d? | 2007-12-04 | 2007-12-04 |  |  |  | 2007-12-04 |  | 618d | finish no earlier than 2007-12-04 | CF | ML3 | MS3CO_035 |
| 179 | 3.7.33 | Central Utility Plant Co-Occupancy | milestone | 1d? | 2007-12-20 | 2007-12-20 |  |  |  | 2007-12-20 |  | 606d | finish no earlier than 2007-12-20 | CF | ML3 | MS3CO_040 |
| 180 | 3.7.34 | Near Experimental Hall Co-Occupancy | milestone | 1d? | 2007-12-20 | 2007-12-20 |  |  |  | 2007-12-20 |  | 606d | finish no earlier than 2007-12-20 | CF | ML3 | MS3CO_020 |
| 181 | 3.7.35 | X-Ray Transport Co-Occupancy | milestone | 1d? | 2008-01-07 | 2008-01-07 |  |  |  | 2008-01-07 |  | 603d | finish no earlier than 2008-01-07 | CF | ML3 | MS3CO_025 |
| 182 | 3.7.36 | X-Ray Transport Beneficial Occupancy | milestone | 0d | 2008-06-20 | 2008-06-20 |  |  | 2007-09-13 | 2008-06-20 | 0d | 484d | finish no earlier than 2008-06-20 | CF | ML3 | MS3BO_055 |
| 183 | 3.7.37 | B028 Beneficial Occupancy | milestone | 0d | 2009-05-05 | 2009-05-05 |  |  | 2007-09-13 | 2008-11-12 | 0d | 268d | finish no earlier than 2009-05-05 | CF | ML3 | MS3BO_075 |
| 184 | 3.7.38 | FEH Hutches Beneficial Occupancy | milestone | 0d | 2009-07-01 | 2009-07-01 |  |  | 2007-09-13 |  | 0d | 227d | finish no earlier than 2009-07-01 | CF | ML3 | MS3BO_080 |
| 186 | 4 | Baseline Milestone Symbol | milestone | 0d | 2009-03-31 | 2009-03-31 |  |  | 2000-10-01 | 2009-03-31 | 0d | 294d | finish no earlier than 2009-03-31 |  | Notes |  |
| 187 | 5 | Projected Milestone Symbol | milestone | 0d | 2009-03-31 | 2009-03-31 |  |  | 2000-10-01 | 2009-03-31 | 0d | 294d | finish no earlier than 2009-03-31 |  |  |  |
| 188 | 6 | Achieved Milestone Symbol | milestone | 0d | 2009-03-31 | 2009-03-31 |  |  | 2000-10-01 | 2009-03-31 | 0d | 294d | finish no earlier than 2009-03-31 |  |  |  |
